# Zwembad plaatsen – Jodoigne – Rue des anges 14

How a schedule from MS Project changed from version to version. A marks actual dates.

## Version 1 (saved 2025-04-30, file Zwembad Jodoigne V3.mpp)

| ID | WBS | Task | Duration | Start | Finish | Predecessors | Total float |
| --- | --- | --- | --- | --- | --- | --- | --- |
| 1 | 1 | **Voorbereiding** | 18.5d | 2025-05-05 | 2025-06-02 |  | 0d |
| 2 |  | Concept - klant ontmoeten | 1w | 2025-05-05 | 2025-05-09 |  | 7.12d |
| 3 |  | Analyse van de leidingen | 1d | 2025-05-09 | 2025-05-09 | 2FF | 7.12d |
| 4 |  | Werf voorbereiden | 1d | 2025-05-28 | 2025-06-02 | 10 | 0d |
| 5 |  | Voorschot ontvangen | 0d | 2025-05-15 | 2025-05-15 | 3 |  |
| 6 | 2 | **Ontwerpfase** | 17.5d | 2025-05-05 | 2025-05-28 |  | 0d |
| 7 |  | Opmeten | 2d | 2025-05-12 | 2025-05-13 | 3 | 7.12d |
| 8 |  | Plan tekenen | 1d | 2025-05-14 | 2025-05-14 | 7 | 7.12d |
| 9 |  | Vergunning aanvragen | 2w | 2025-05-05 | 2025-05-28 |  | 0d |
| 10 |  | Go / nogo | 0d | 2025-05-28 | 2025-05-28 | 9, 5 | 0d |
| 11 | 3 | **Bestellingen** | 7.38d | 2025-05-19 | 2025-05-28 |  | 3.12d |
| 12 |  | Offertes aanvragen | 3d | 2025-05-19 | 2025-05-26 | 8 | 3.12d |
| 13 |  | Bestellen van ijzer, hout, tegels, … | 0.25w | 2025-05-20 | 2025-05-26 | 14FF-2d | 5.12d |
| 14 |  | Bestellen van de pompen | 0.38w | 2025-05-26 | 2025-05-28 | 12 | 3.12d |
| 15 | 4 | **Graafwerken** | 2.5d | 2025-06-02 | 2025-06-04 |  | 0d |
| 16 |  | Uitgraven van de zwembad zone | 1d | 2025-06-02 | 2025-06-03 | 4 | 0d |
| 17 |  | Afvoeren van de aarde | 1d | 2025-06-03 | 2025-06-04 | 16 | 0d |
| 18 |  | Uitgraven ivm technische ruimte | 0.5d | 2025-06-04 | 2025-06-04 | 17 | 0d |
| 19 | 5 | **Werkvloer** | 1d | 2025-06-05 | 2025-06-05 | 15, 11 | 0d |
| 20 |  | Afvoerbuizen plaatsen | 1d | 2025-06-05 | 2025-06-05 |  | 19d |
| 21 |  | Dichtingen uitvoeren | 1d | 2025-06-05 | 2025-06-05 |  | 19d |
| 22 |  | Beton gieten | 1d | 2025-06-05 | 2025-06-05 |  | 0d |
| 23 | 6 | **Installatie van het zwembad** | 14.5d | 2025-06-10 | 2025-06-30 |  | 0d |
| 24 |  | Bekisting aanbrengen | 2d | 2025-06-10 | 2025-06-11 | 22FS+1d | 0d |
| 25 |  | Betonneren | 2d | 2025-06-12 | 2025-06-13 | 24 | 0d |
| 26 |  | Ontkisten | 1.5d | 2025-06-16 | 2025-06-17 | 25 | 0d |
| 27 |  | Poolhouse plaatsen | 2d | 2025-06-12 | 2025-06-13 | 25SS | 12d |
| 28 |  | Pompen en leidingen installeren | 4d | 2025-06-16 | 2025-06-19 | 27 | 10d |
| 29 |  | Tegels plaatsen | 4d | 2025-06-24 | 2025-06-30 | 26FS+1w | 0d |
| 30 | 7 | **Afwerken** | 3.5d | 2025-06-30 | 2025-07-03 |  | 0d |
| 31 |  | Voegen | 1.5d | 2025-06-30 | 2025-07-01 | 29 | 0d |
| 32 |  | Aanvullingen rond zwembad | 1d | 2025-07-02 | 2025-07-02 | 31 | 1d |
| 33 |  | graszoden plaatsen | 1d | 2025-07-02 | 2025-07-02 | 31 | 1d |
| 34 |  | Vullen met water | 1d | 2025-07-02 | 2025-07-02 | 31 | 0d |
| 35 |  | Testen | 1d | 2025-07-03 | 2025-07-03 | 34 | 0d |
| 36 |  | Oplevering | 0d | 2025-07-03 | 2025-07-03 | 35 | 0d |

## Version 2 (saved 2025-04-30, file Zwembad Jodoigne V4.mpp)

Last finish 2025-07-03 → 2025-07-07 (+4d). Complete tasks 0 → 10.

Changed:

| ID | Task | Start | Finish | Duration | Complete | Total float | Predecessors | Other |
| --- | --- | --- | --- | --- | --- | --- | --- | --- |
| 1 | **Voorbereiding** | 2025-05-05 A | 2025-06-02 → 2025-06-04 A (+2d) | 18.5d → 21d | 0% → 100% | 0d → none |  | baseline start none → 2025-05-05; baseline finish none → 2025-06-02 |
| 2 | Concept - klant ontmoeten | 2025-05-05 A | 2025-05-09 A |  | 0% → 100% | 7.12d → none |  | baseline start none → 2025-05-05; baseline finish none → 2025-05-09 |
| 3 | Analyse van de leidingen | 2025-05-09 → 2025-05-14 A (+5d) | 2025-05-09 → 2025-05-14 A (+5d) |  | 0% → 100% | 7.12d → none |  | baseline start none → 2025-05-09; baseline finish none → 2025-05-09 |
| 4 | Werf voorbereiden | 2025-05-28 → 2025-06-03 A (+6d) | 2025-06-02 → 2025-06-04 A (+2d) | 1d → 2d | 0% → 100% | 0d → none |  | baseline start none → 2025-05-28; baseline finish none → 2025-06-02 |
| 5 | Voorschot ontvangen | 2025-05-15 → 2025-05-20 A (+5d) | 2025-05-15 → 2025-05-20 A (+5d) |  | 0% → 100% |  |  | baseline start none → 2025-05-15; baseline finish none → 2025-05-15 |
| 6 | **Ontwerpfase** | 2025-05-05 A | 2025-05-28 → 2025-05-30 A (+2d) | 17.5d → 18d | 0% → 100% | 0d → none |  | baseline start none → 2025-05-05; baseline finish none → 2025-05-28 |
| 7 | Opmeten | 2025-05-12 → 2025-05-19 A (+7d) | 2025-05-13 → 2025-05-21 A (+8d) | 2d → 3d | 0% → 100% | 7.12d → none |  | baseline start none → 2025-05-12; baseline finish none → 2025-05-13 |
| 8 | Plan tekenen | 2025-05-14 → 2025-05-22 A (+8d) | 2025-05-14 → 2025-05-28 A (+14d) | 1d → 5d | 0% → 100% | 7.12d → none |  | baseline start none → 2025-05-14; baseline finish none → 2025-05-14 |
| 9 | Vergunning aanvragen | 2025-05-05 A | 2025-05-28 A | 2w → 3.5w | 0% → 100% | 0d → none |  | baseline start none → 2025-05-05; baseline finish none → 2025-05-28 |
| 10 | Go / nogo | 2025-05-28 → 2025-05-30 A (+2d) | 2025-05-28 → 2025-05-30 A (+2d) |  | 0% → 100% | 0d → none | 9, 5 → 9, 5, 8 | baseline start none → 2025-05-28; baseline finish none → 2025-05-28 |
| 11 | **Bestellingen** | 2025-05-19 → 2025-06-02 A (+14d) | 2025-05-28 → 2025-06-11 (+14d) | 7.38d → 6.5d | 0% → 38% | 3.12d → 0d |  | baseline start none → 2025-05-19; baseline finish none → 2025-05-28 |
| 12 | Offertes aanvragen | 2025-05-19 → 2025-06-02 A (+14d) | 2025-05-26 → 2025-06-03 A (+8d) | 3d → 2d | 0% → 100% | 3.12d → none |  | baseline start none → 2025-05-19; baseline finish none → 2025-05-26 |
| 13 | Bestellen van ijzer, hout, tegels, … | 2025-05-20 → 2025-06-03 (+14d) | 2025-05-26 → 2025-06-06 (+11d) |  |  | 5.12d → 2d |  | baseline start none → 2025-05-20; baseline finish none → 2025-05-26 |
| 14 | Bestellen van de pompen | 2025-05-26 → 2025-06-04 (+9d) | 2025-05-28 → 2025-06-11 (+14d) | 0.38w → 2d |  | 3.12d → 0d |  | baseline start none → 2025-05-26; baseline finish none → 2025-05-28 |
| 15 | **Graafwerken** | 2025-06-02 → 2025-06-05 A (+3d) | 2025-06-04 → 2025-06-10 (+6d) | 2.5d → 2.12d | 0% → 29% | 0d → 1.38d |  | baseline start none → 2025-06-02; baseline finish none → 2025-06-04 |
| 16 | Uitgraven van de zwembad zone | 2025-06-02 → 2025-06-05 A (+3d) | 2025-06-03 → 2025-06-05 A (+2d) | 1d → 0.62d | 0% → 100% | 0d → none |  | baseline start none → 2025-06-02; baseline finish none → 2025-06-03 |
| 17 | Afvoeren van de aarde | 2025-06-03 → 2025-06-05 (+2d) | 2025-06-04 → 2025-06-06 (+2d) |  |  | 0d → 1.38d |  | baseline start none → 2025-06-03; baseline finish none → 2025-06-04 |
| 18 | Uitgraven ivm technische ruimte | 2025-06-04 → 2025-06-06 (+2d) | 2025-06-04 → 2025-06-10 (+6d) |  |  | 0d → 1.38d |  | baseline start none → 2025-06-04; baseline finish none → 2025-06-04 |
| 19 | **Werkvloer** | 2025-06-05 → 2025-06-11 (+6d) | 2025-06-05 → 2025-06-12 (+7d) |  |  |  |  | baseline start none → 2025-06-05; baseline finish none → 2025-06-05 |
| 20 | Afvoerbuizen plaatsen | 2025-06-05 → 2025-06-11 (+6d) | 2025-06-05 → 2025-06-12 (+7d) |  |  | 19d → 17d |  | baseline start none → 2025-06-05; baseline finish none → 2025-06-05 |
| 21 | Dichtingen uitvoeren | 2025-06-05 → 2025-06-11 (+6d) | 2025-06-05 → 2025-06-12 (+7d) |  |  | 19d → 17d |  | baseline start none → 2025-06-05; baseline finish none → 2025-06-05 |
| 22 | Beton gieten | 2025-06-05 → 2025-06-11 (+6d) | 2025-06-05 → 2025-06-12 (+7d) |  |  |  |  | baseline start none → 2025-06-05; baseline finish none → 2025-06-05 |
| 23 | **Installatie van het zwembad** | 2025-06-10 → 2025-06-13 (+3d) | 2025-06-30 → 2025-07-01 (+1d) | 14.5d → 12.5d |  |  |  | baseline start none → 2025-06-10; baseline finish none → 2025-06-30 |
| 24 | Bekisting aanbrengen | 2025-06-10 → 2025-06-13 (+3d) | 2025-06-11 → 2025-06-17 (+6d) |  |  |  |  | baseline start none → 2025-06-10; baseline finish none → 2025-06-11 |
| 25 | Betonneren | 2025-06-12 → 2025-06-17 (+5d) | 2025-06-13 → 2025-06-19 (+6d) |  |  |  |  | baseline start none → 2025-06-12; baseline finish none → 2025-06-13 |
| 26 | Ontkisten | 2025-06-16 → 2025-06-19 (+3d) | 2025-06-17 → 2025-06-20 (+3d) |  |  |  |  | baseline start none → 2025-06-16; baseline finish none → 2025-06-17 |
| 27 | Poolhouse plaatsen | 2025-06-12 → 2025-06-17 (+5d) | 2025-06-13 → 2025-06-19 (+6d) |  |  | 12d → 8d |  | baseline start none → 2025-06-12; baseline finish none → 2025-06-13 |
| 28 | Pompen en leidingen installeren | 2025-06-16 → 2025-06-19 (+3d) | 2025-06-19 → 2025-06-25 (+6d) |  |  | 10d → 8d |  | baseline start none → 2025-06-16; baseline finish none → 2025-06-19 |
| 29 | Tegels plaatsen | 2025-06-24 → 2025-06-30 (+6d) | 2025-06-30 → 2025-07-01 (+1d) | 4d → 2d |  |  |  | baseline start none → 2025-06-24; baseline finish none → 2025-06-30 |
| 30 | **Afwerken** | 2025-06-30 → 2025-07-02 (+2d) | 2025-07-03 → 2025-07-07 (+4d) |  |  |  |  | baseline start none → 2025-06-30; baseline finish none → 2025-07-03 |
| 31 | Voegen | 2025-06-30 → 2025-07-02 (+2d) | 2025-07-01 → 2025-07-03 (+2d) |  |  |  |  | baseline start none → 2025-06-30; baseline finish none → 2025-07-01 |
| 32 | Aanvullingen rond zwembad | 2025-07-02 → 2025-07-03 (+1d) | 2025-07-02 → 2025-07-04 (+2d) |  |  |  |  | baseline start none → 2025-07-02; baseline finish none → 2025-07-02 |
| 33 | graszoden plaatsen | 2025-07-02 → 2025-07-03 (+1d) | 2025-07-02 → 2025-07-04 (+2d) |  |  |  |  | baseline start none → 2025-07-02; baseline finish none → 2025-07-02 |
| 34 | Vullen met water | 2025-07-02 → 2025-07-03 (+1d) | 2025-07-02 → 2025-07-04 (+2d) |  |  |  |  | baseline start none → 2025-07-02; baseline finish none → 2025-07-02 |
| 35 | Testen | 2025-07-03 → 2025-07-04 (+1d) | 2025-07-03 → 2025-07-07 (+4d) |  |  |  |  | baseline start none → 2025-07-03; baseline finish none → 2025-07-03 |
| 36 | Oplevering | 2025-07-03 → 2025-07-07 (+4d) | 2025-07-03 → 2025-07-07 (+4d) |  |  |  |  | baseline start none → 2025-07-03; baseline finish none → 2025-07-03 |
